# WP5

Schedule from MS Project, 2005-10-03 to 2009-03-31, A marks actual dates.
CLRC

## Calendars

- Standard: Mon-Fri 08:00-12:00, 13:00-17:00; Sat-Sun off.

## Schedule

| ID | WBS | Task | Type | Duration | Start | Finish | Predecessors | Complete | Remaining | Total slack | Constraint |
| --- | --- | --- | --- | --- | --- | --- | --- | --- | --- | --- | --- |
| 1 | 1 | **CALICE WP5** |  | 912d? | 2005-10-03 A | 2009-03-31 |  | 28% | 658.94d? | 0d |  |
| 2 | 1.1 | **Energy flow algorithms** |  | 912d? | 2005-10-03 A | 2009-03-31 |  | 32% | 617.71d? | 0d |  |
| 3 | 1.1.1 | Resolution/algorithm brainstorming |  | 64d | 2005-10-03 A | 2005-12-29 A |  | 100% |  |  | finish no earlier than 2005-12-29 |
| 4 | 1.1.2 | Comparison of existing PFAs (delete?) | milestone | 0d | 2006-06-30 A | 2006-06-30 A |  | 100% |  |  | start no earlier than 2006-06-30 |
| 5 | 1.1.3 | Tools definition |  | 130d | 2006-01-02 A | 2006-06-30 A |  | 100% |  |  | start no earlier than 2006-01-02 |
| 6 | 1.1.4 | Evaluation of existing code |  | 130d? | 2006-04-03 A | 2006-09-29 | 2 | 70% | 39d? | 652d |  |
| 7 | 1.1.5 | Algorithm implementation |  | 230d | 2005-10-03 A | 2006-08-18 A |  | 100% |  |  | start no earlier than 2005-10-03 |
| 8 | 1.1.6 | Release of V1 of algorithm | milestone | 0d | 2006-08-18 A | 2006-08-18 A | 7 | 100% |  |  | start no earlier than 2006-08-18 |
| 9 | 1.1.7 | Algorithm development |  | 682d | 2006-08-21 | 2009-03-31 | 8 |  |  | 0d |  |
| 10 | 1.1.8 | Physics benchmarking |  | 360d? | 2006-08-21 | 2008-01-04 | 8, 6 |  |  | 322d |  |
| 11 | 1.1.9 | Presentation of physics benchmark results at LCWS07 | milestone | 0d | 2007-04-16 | 2007-04-16 |  |  |  | 512d | start no earlier than 2007-04-16 |
| 12 | 1.2 | **Global detector design** |  | 805d? | 2005-10-03 A | 2008-10-31 |  | 24% | 612.78d? | 107d |  |
| 13 | 1.2.1 | Performance of single particles (LDC) |  | 175d? | 2005-10-03 A | 2006-12-29 |  | 75% | 43.75d? | 587d |  |
| 14 | 1.2.2 | Present initial results from single particle studies | milestone | 0d | 2006-03-31 A | 2006-03-31 A |  | 100% |  |  | start no earlier than 2006-03-31 |
| 15 | 1.2.3 | Performance physics benchmark (LDC) |  | 260d | 2006-01-02 A | 2006-12-29 |  | 70% | 78d | 587d | start no earlier than 2006-01-02 |
| 16 | 1.2.4 | Present first physics benchmark at Valencia | milestone | 0d | 2006-11-15 | 2006-11-15 |  |  |  | 0d | must finish on 2006-11-15 |
| 17 | 1.2.5 | Extension to other detector concepts |  | 195d | 2006-10-02 A | 2007-06-29 |  | 5% | 185.25d | 457d | start no earlier than 2006-10-01 |
| 18 | 1.2.6 | Further physics benchmarks |  | 478d? | 2006-06-01 A | 2008-03-31 |  | 15% | 406.3d? | 261d |  |
| 19 | 1.2.7 | Detector parameter optimization |  | 545d? | 2006-10-02 | 2008-10-31 |  |  |  | 107d | start no earlier than 2006-10-02 |
| 20 | 1.3 | **Workpackage support** |  | 912d? | 2005-10-03 A | 2009-03-31 |  | 31% | 627.97d? | 0d |  |
| 21 | 1.3.1 | DAQ local clustering |  | 195d? | 2006-07-03 | 2007-03-30 |  |  |  | 522d | finish no earlier than 2007-03-30 |
| 22 | 1.3.2 | Mechanical imperfections (1) |  | 65d? | 2007-04-02 | 2007-06-29 |  |  |  | 457d | start no earlier than 2007-04-01 |
| 23 | 1.3.3 | Mechanical imperfections (2) |  | 131d? | 2007-10-01 | 2008-03-31 |  |  |  | 261d | start no earlier than 2007-10-01 |
| 24 | 1.3.4 | First results from mechanical imperfections simulations | milestone | 0d | 2007-12-31 | 2007-12-31 |  |  |  | 327d | start no earlier than 2007-12-31 |
| 25 | 1.3.5 | MAPS into Mokka |  | 195d? | 2005-10-03 A | 2006-06-30 A |  | 100% |  |  | finish no earlier than 2006-06-30 |
| 26 | 1.3.6 | MAPS implemented in Mokka | milestone | 0d | 2006-05-31 A | 2006-05-31 A |  | 100% |  |  | start no earlier than 2006-05-31 |
| 27 | 1.3.7 | MAPS sensor variation studies |  | 260d? | 2006-04-03 A | 2007-03-30 |  | 65% | 90d? | 522d |  |
| 28 | 1.3.8 | Simulations for MAPS test beam | milestone | 0d | 2008-03-31 | 2008-03-31 |  |  |  | 262d | start no earlier than 2008-03-31 |
| 29 | 1.3.9 | MAPS test beam |  | 326d? | 2008-01-01 | 2009-03-31 |  |  |  | 0d | start no earlier than 2008-01-01 |

Notes:
- 4: Earlier PFA algorithms difficult to handle as not in Marlin framework. Consider Wolf as the existing code now. To all intents and purposes, earlier codes are not looked at except by their authors (e.g. Vasily Morgunov).
- 6: COmparison of Wolf, the existing particle flow algorithm, is implicit in physics and clustering studies.
- 8: Mark Thomson is developing "PandoraPFA", an alternative to the default/standard "Wolf" particle flow algorithm currently distributed with Marlin/MarlinReco. He released the code to a select few colleagues in Jul/Aug 2006, with version more widely available at 16-Aug meeting, see http://ilcagenda.cern.ch/materialDisplay.py?contribId=5&amp;materialId=slides&amp;confId=1040
- 9: Follows on from release of first version of code. "Users" of the code will feedback on its performance in various situations and e.g. with variation of the hadronication interaction model chosen in Geant4.
- 10: Extended (in Sep. 2006) as anticipate this will continue for much of the project
- 11: At an appropriate workshop or simulation group meeting
- 13: Split into two phases, allowing for re-evaluation at a later stage in LDC detector design
- 14: Results in LDC Detector Outline Document, as at LCWS06 (Bangalor)
- 15: Results included in Mar. 2006 OsC report.
- 17: Need to be sure analysis is robust within single detector concept before attempting to extend it to alternative detector model. Propose to use detector models with Mokka for technical simplicity, e.g. use Mokka with its superdrivers to study SiD and at same time generate GEAR file for geometry (in part). Nigel has tried this feature for simple clustering studies in Aug. 2006 but not yet passed on the geometry file to Michele / Fab to test in their physics studies.
- 18: Wenbiao et al have started WW/ZZ study, separation of reconstructed invariant masses, with fitting of reconstructed dijets using each of parton level, hadron level and particle flow objects, see latest progress at: http://www.ep.ph.bham.ac.uk/exp/CALICE/sim/meetings/10aug2006_minutes.html
- 21: Not yet started
- 26: Implemented the separate epitaxial and substrate layers nito LDC01 model (Yoshi M.). / Not included in general release of mokka yet, but tried by Anne-Marie M., Nigel W. and Yoshi to generate event samples. LCIO format adapted to allow 5 micron cell sizes (Encoder64.hh). / Simulation studies of clustering algorithms using this MAPS implementation are underway, see e.g. / http://www.hep.ph.ic.ac.uk/~calice/mapsMeetings/060906ral/hopkinson.pdf
- 27: Studies of varying sensor size are well underway. Still to investigate effects of inter-layer gaps and understand the number of MC particles per pixel.

| ID | WBS | Task | Type | Duration | Start | Finish | Predecessors | Complete | Remaining | Total slack | Constraint |
| --- | --- | --- | --- | --- | --- | --- | --- | --- | --- | --- | --- |
| 30 | 1.4 | **Physics studies** |  | 912d? | 2005-10-03 A | 2009-03-31 |  | 24% | 691.99d? | 0d |  |
| 31 | 1.4.1 | Survey existing analyses/benchmarks |  | 65d? | 2005-10-03 A | 2005-12-30 A |  | 100% |  |  | start no earlier than 2005-10-03 |
| 32 | 1.4.2 | Implement first analysis |  | 195d? | 2006-01-02 A | 2006-09-29 |  | 95% | 10d? | 0d |  |
| 33 | 1.4.3 | Status report at regional workshop | milestone | 0d | 2006-05-01 A | 2006-05-01 A |  | 100% |  |  | start no earlier than 2006-05-01 |
| 34 | 1.4.4 | Generic physics analysis implemented | milestone | 0d | 2006-09-30 A | 2006-09-30 | 32 | 95% | 0d | 652d |  |
| 35 | 1.4.5 | Develop alternative analysis benchmark |  | 347d? | 2006-06-01 A | 2007-09-28 |  | 20% | 277.6d? | 392d |  |
| 36 | 1.4.6 | Alternative benchmark analysis available | milestone | 0d | 2007-09-30 | 2007-09-30 |  |  |  | 392d | start no earlier than 2007-09-30 |
| 37 | 1.4.7 | Sensitivy to hadronic interaction modelling |  | 717d? | 2006-07-03 | 2009-03-31 |  |  |  | 0d | start no earlier than 2006-07-01 |
| 38 | 1.4.8 | Report on hadronic modelling studies with test beam results | milestone | 0d | 2008-06-30 | 2008-06-30 |  |  |  | 197d | start no earlier than 2008-06-30 |

Notes:
- 32: ZHH analysis of Michele et al, reported to Mar. 2006 OsC meeting.
- 34: Our understanding of "generic" is now slightly different - we now mean an analysis in which those aspects which can reasonably be treated generically are done so. For example, the geometry ideally can be defined via a GEAR xml file, but names of collections of hits, etc. will always have to be changed, depending upon whether events were generated by Mokka or slic or Jupiter or ...
- 35: WW/ZZ separation study by Wenbiao, see: http://www.ep.ph.bham.ac.uk/exp/CALICE/sim/meetings/10aug2006_minutes.html
- 37: To start in parallel with testing of PandoraPFA with event samples generated with different models within Geant4.
